# DBB Outline Generic 150408

Schedule from MS Project, 2015-04-06 to 2019-11-26.
DPW

## Calendars

- Standard: Mon-Sun 08:00-12:00, 13:00-17:00.

## Schedule

| ID | WBS | Task | Type | Duration | Start | Finish | Predecessors | Baseline start | Baseline finish | Baseline duration | Total slack | Constraint |
| --- | --- | --- | --- | --- | --- | --- | --- | --- | --- | --- | --- | --- |
| 1 | 1 | **Project Totals** |  | 1696d | 2015-04-06 | 2019-11-26 |  |  |  |  | 0d |  |
| 2 | 1.1 | **Planning (OPM B-100 Process) + DCS Project Initiation** |  | 30d | 2015-04-06 | 2015-05-05 |  | 1996-12-23 | 1997-04-25 | 90d | 0d |  |
| 3 | 1.1.1 | Agency Program Development (3mo.) | milestone | 0d | 2015-04-06 | 2015-04-06 |  |  |  |  | 1696d |  |
| 4 | 1.1.2 | AGENCY PLANNING, + Equipment Needs, Cost Est., etc. (3mo.) | milestone | 0d | 2015-04-06 | 2015-04-06 |  |  |  |  | 1696d |  |
| 5 | 1.1.3 | Agency to Review OPM B-100 draft w/ DPW ADPM (or PM) | milestone | 0d | 2015-04-06 | 2015-04-06 |  |  |  |  | 1696d |  |
| 6 | 1.1.4 | State-OPM Capitol Budget Process (12mo.) + Authorization | milestone | 0d | 2015-04-06 | 2015-04-06 |  |  |  |  | 0d |  |
| 7 | 1.1.5 | Receive "DCS" B-100S from Agency | milestone | 0d | 2015-04-06 | 2015-04-06 | 6 |  |  |  | 0d |  |
| 8 | 1.1.6 | Review B-100 Supplement with Agency & DPW Resources |  | 10d | 2015-04-06 | 2015-04-15 | 7 | 1996-12-23 | 1997-01-03 | 10d | 0d |  |
| 9 | 1.1.7 | Accept/Approve B100S (Milestone #1) by ADPM | milestone | 0d | 2015-04-15 | 2015-04-15 | 8 |  |  |  | 0d |  |
| 10 | 1.1.8 | Obtain Project Number + Open in Core-CT & PMWeb |  | 1d | 2015-04-16 | 2015-04-16 | 9 |  |  |  | 0d |  |
| 11 | 1.1.9 | Define Environmental Issues (CEPA,EIE,STC) & Utility Service status (see check list) |  | 5d | 2015-04-17 | 2015-04-21 | 10 |  |  |  | 0d |  |
| 12 | 1.1.10 | Define HazMat requirements and Approach (see inspection request) |  | 5d | 2015-04-16 | 2015-04-20 | 8 |  |  |  | 15d |  |
| 13 | 1.1.11 | DPW In-take meeting and Project Plan Preparation & Review |  | 14d | 2015-04-22 | 2015-05-05 | 11 |  |  |  | 0d |  |
| 14 | 1.1.12 | Project Plan Approved | milestone | 0d | 2015-05-05 | 2015-05-05 | 13 |  |  |  | 0d |  |
| 15 | 1.2 | **AE/CA Selection and Contract + Funding & DCS Management** |  | 251d | 2015-05-06 | 2016-01-11 |  |  |  |  | 0d |  |
| 16 | 1.2.1 | Advertise and Formal A/E Selection - Receive draft ad from PM & process |  | 15d | 2015-05-06 | 2015-05-20 | 14, 12 | 1997-01-03 | 1997-04-24 | 80d | 0d |  |
| 17 | 1.2.2 | Publish A/E & CA Advertisement | milestone | 0d | 2015-05-20 | 2015-05-20 | 16, 12 |  |  |  | 0d |  |
| 18 | 1.2.3 | A/E & CA Firms Prepare QBS Submission Package |  | 28d | 2015-05-21 | 2015-06-17 | 17 |  |  |  | 0d |  |
| 19 | 1.2.4 | DPW Receives QBS Submission Packages from A/E & CA | milestone | 0d | 2015-06-17 | 2015-06-17 | 18 |  |  |  | 0d |  |
| 20 | 1.2.5 | DPW Short listing Meeting (1+ week after receipt) |  | 7d | 2015-06-18 | 2015-06-24 | 19 |  |  |  | 0d |  |
| 21 | 1.2.6 | Ballots Summary + Memo + Commissioner Approval of Short List |  | 5d | 2015-06-25 | 2015-06-29 | 20 |  |  |  | 0d |  |
| 22 | 1.2.7 | Proposal Meeting w/ short listed firms (at site) + Firms prepare presentation |  | 21d | 2015-06-30 | 2015-07-20 | 21 |  |  |  | 0d |  |
| 23 | 1.2.8 | INTERVIEWS for A/E and CA | milestone | 0d | 2015-07-20 | 2015-07-20 | 22 |  |  |  | 0d |  |
| 24 | 1.2.9 | Process Selection Ballots + Commissioner Approval |  | 6d | 2015-07-21 | 2015-07-26 | 23 |  |  |  | 0d |  |
| 25 | 1.2.10 | A/E Conditional Selection Letter (Milestone #2) | milestone | 0d | 2015-07-26 | 2015-07-26 | 24 |  |  |  | 0d |  |
| 26 | 1.2.11 | PM Negotiation & Scoping both A/E & CA |  | 21d | 2015-07-27 | 2015-08-16 | 25 | 1996-12-23 | 1997-01-10 | 15d | 0d |  |
| 27 | 1.2.12 | A/E Credentials Submission to & Approval by Legal |  | 30d | 2015-07-27 | 2015-08-25 | 25 |  |  |  | 1554d |  |
| 28 | 1.2.13 | Finalize Scope & Fees and Budget (w/agency input) |  | 5d | 2015-08-17 | 2015-08-21 | 26 |  |  |  | 0d |  |
| 29 | 1.2.14 | Submit bonding request - place holder w/estimate |  | 10d | 2015-08-22 | 2015-08-31 | 28 |  |  |  | 1548d |  |
| 30 | 1.2.15 | Process Contract ( & Exhibit A) by PM & DPW Legal, plus package for SPRB XX ADD/REDUCE TIME? XX |  | 85d | 2015-08-22 | 2015-11-14 | 28, 26 | 1996-12-23 | 1997-02-07 | 35d | 0d | start no earlier than 1997-05-11 |
| 31 | 1.2.16 | SPRB Submission and Review |  | 14d | 2015-11-15 | 2015-11-28 | 30 |  |  |  | 0d |  |
| 32 | 1.2.17 | SPRB Approval | milestone | 0d | 2015-11-28 | 2015-11-28 | 31 |  |  |  | 0d |  |
| 33 | 1.2.18 | Request Bonding for Design & CA, & Bond Commission Process Time |  | 30d | 2015-11-29 | 2015-12-28 | 32 | 1996-12-23 | 1997-01-17 | 20d | 0d | start no earlier than 1997-12-28 |
| 34 | 1.2.19 | Bond Commission Approval - (Funding in place) | milestone | 0d | 2015-12-28 | 2015-12-28 | 33 |  |  |  | 0d |  |
| 35 | 1.2.20 | A.G. Approval of Executed Contract (Legal says plan 7 to 21 days) |  | 14d | 2015-12-29 | 2016-01-11 | 34 |  |  |  | 0d |  |
| 36 | 1.2.21 | Notice to Proceed for Design Firm ( & for CA) | milestone | 0d | 2016-01-11 | 2016-01-11 | 35 |  |  |  | 0d |  |

| ID | WBS | Task | Type | Duration | Start | Finish | Predecessors | Baseline start | Baseline finish | Baseline duration | Total slack | Free slack | Constraint |
| --- | --- | --- | --- | --- | --- | --- | --- | --- | --- | --- | --- | --- | --- |
| 37 | 1.3 | **DESIGN PHASE (with Programming)** |  | 439d | 2016-01-11 | 2017-03-25 |  | 1996-12-23 | 1997-02-14 | 40d | 0d |  |  |
| 38 | 1.3.1 | A/E Starts Design Contract Services ( Milestone #3) | milestone | 0d | 2016-01-11 | 2016-01-11 | 36 |  |  |  | 0d |  |  |
| 39 | 1.3.2 | **Programming ( * PM to adjust for each project)** |  | 36d | 2016-01-12 | 2016-02-16 | 38 |  |  |  | 0d |  |  |
| 40 | 1.3.2.1 | Programming 75% Submission to DPW |  | 21d | 2016-01-12 | 2016-02-01 | 38 |  |  |  | 0d |  |  |
| 41 | 1.3.2.2 | Programming Review Mtg w/ Client Agency |  | 5d | 2016-02-02 | 2016-02-06 | 40 |  |  |  | 0d |  |  |
| 42 | 1.3.2.3 | Programming Final Submission |  | 5d | 2016-02-07 | 2016-02-11 | 41 |  |  |  | 0d |  |  |
| 43 | 1.3.2.4 | Programming Approved by Client Agency and DPW PM |  | 5d | 2016-02-12 | 2016-02-16 | 42 |  |  |  | 0d |  |  |
| 44 | 1.3.2.5 | Programming Completed & Environment/HazMat Evaluation Completed Milestone | milestone | 0d | 2016-02-16 | 2016-02-16 | 43 |  |  |  | 0d |  |  |
| 45 | 1.3.3 | **HazMat Evaluation** |  | 9d | 2016-01-12 | 2016-01-20 | 38 | 1996-12-23 | 1996-12-23 | 1d | 27d |  |  |
| 46 | 1.3.3.1 | HazMat Design and Coordination ( * PM to adjust for each project) |  | 9d | 2016-01-12 | 2016-01-20 | 38 |  |  |  | 27d |  |  |
| 47 | 1.3.4 | **Environmental Evaluation FONSI/EIE** |  | 36d | 2016-01-12 | 2016-02-16 | 38 | 1996-12-23 | 1997-02-14 | 40d | 16d |  |  |
| 48 | 1.3.4.1 | DEP/EIE/STC Permitting ( * PM to adjust for each project) |  | 10d | 2016-01-12 | 2016-01-21 | 38 |  |  |  | 26d |  |  |
| 49 | 1.3.4.2 | Survey, Wetlands ID, Borings, consider local zoning |  | 15d | 2016-01-12 | 2016-01-26 | 38 | 1996-12-23 | 1997-01-03 | 10d | 90d | 22d |  |
| 50 | 1.3.4.3 | Land Acq./Easements Evaluation XX If req'd. add time!!XX |  | 20d | 2016-01-12 | 2016-01-31 | 38 | 1996-12-23 | 1997-01-17 | 20d | 16d |  |  |
| 51 | 1.3.4.4 | Notice to Proceed with Schematics (Milestone) | milestone | 0d | 2016-02-16 | 2016-02-16 | 48, 43, 44, 46, 50 |  |  |  | 0d |  |  |
| 52 | 1.3.5 | **Schematics (Preliminary Design)** |  | 101d | 2016-02-17 | 2016-05-27 | 51 | 1996-12-23 | 1997-01-17 | 20d | 0d |  |  |
| 53 | 1.3.5.1 | Schematic Design Progress ( * PM to adjust for each project) |  | 70d | 2016-02-17 | 2016-04-26 | 51 |  |  |  | 0d |  |  |
| 54 | 1.3.5.2 | LEED Mtg (Sustainable Design Approach) |  | 1d | 2016-02-17 | 2016-02-17 | 51 |  |  |  | 68d | 0d |  |
| 55 | 1.3.5.3 | Schematic "50% Review" W/ BD&C Managers/Chief Arch |  | 1d | 2016-02-18 | 2016-02-18 | 51, 54 |  |  |  | 1377d |  |  |
| 56 | 1.3.5.4 | Brainstorm Mtg. w/Utility Cos. [LEED?, HPB?, Commissioning?] |  | 1d | 2016-02-18 | 2016-02-18 | 51, 49, 54 |  |  |  | 68d |  | start no earlier than 1997-08-31 |
| 57 | 1.3.5.5 | Review Supple. Conditions & Working Procedures during const.+ PMWeb |  | 1d | 2016-02-17 | 2016-02-17 | 51 |  |  |  | 69d |  | start no earlier than 1997-08-31 |
| 58 | 1.3.5.6 | Local Fire Dept. Review & Input |  | 1d | 2016-02-17 | 2016-02-17 | 51 |  |  |  | 99d |  | start no earlier than 1997-08-31 |
| 59 | 1.3.5.7 | Schematics Review Comments by Agency, Owner, Others |  | 30d | 2016-04-27 | 2016-05-26 | 53, 57, 56, 54, 50 | 1996-12-23 | 1997-01-03 | 10d | 0d |  | start no earlier than 1997-09-21 |
| 60 | 1.3.5.8 | Budget Reconciliation |  | 1d | 2016-04-27 | 2016-04-27 | 53 |  |  |  | 30d |  |  |
| 61 | 1.3.5.9 | Schematic Issues Resolved & ART status |  | 1d | 2016-05-27 | 2016-05-27 | 59, 58 |  |  |  | 0d |  |  |
| 62 | 1.3.5.10 | Boring & Geotech Report |  | 1d | 2016-04-27 | 2016-04-27 | 53 |  |  |  | 30d |  | start no earlier than 2008-08-11 |
| 63 | 1.3.5.11 | Permits Review Checklist |  | 1d | 2016-04-27 | 2016-04-27 | 53 |  |  |  | 30d |  |  |
| 64 | 1.3.5.12 | Asbestos Coor & Design w/ destructive testing |  | 1d | 2016-04-27 | 2016-04-27 | 53 |  |  |  | 30d |  |  |
| 65 | 1.3.5.13 | Notice to Proceed with Design Development | milestone | 0d | 2016-05-27 | 2016-05-27 | 61, 60, 58, 62, 63, 64 |  |  |  | 0d |  |  |

| ID | WBS | Task | Type | Duration | Start | Finish | Predecessors | Baseline start | Baseline finish | Baseline duration | Total slack | Free slack | Constraint |
| --- | --- | --- | --- | --- | --- | --- | --- | --- | --- | --- | --- | --- | --- |
| 66 | 1.3.6 | **Design Development (Basics)** |  | 117d | 2016-05-28 | 2016-09-21 | 65 | 1996-12-23 | 1997-01-31 | 30d | 0d |  |  |
| 67 | 1.3.6.1 | Design Development Progress ( * PM to adjust for each project ) |  | 85d | 2016-05-28 | 2016-08-20 | 65 |  |  |  | 0d |  |  |
| 68 | 1.3.6.2 | Life Cycle Cost Evaluation |  | 1d | 2016-05-28 | 2016-05-28 | 65 | 1996-12-23 | 1996-12-23 | 1d | 114d |  | start no earlier than 1997-10-12 |
| 69 | 1.3.6.3 | Design Development Review, Agency Approval, Others? |  | 30d | 2016-08-21 | 2016-09-19 | 67 | 1996-12-23 | 1997-01-03 | 10d | 0d |  | start no earlier than 1997-11-16 |
| 70 | 1.3.6.4 | Review Gen Requirements, any "Special Const Phasing / Restrictions" w/ Agency |  | 1d | 2016-09-20 | 2016-09-20 | 69 |  |  |  | 1162d |  |  |
| 71 | 1.3.6.5 | Budget Reconciliation |  | 1d | 2016-08-21 | 2016-08-21 | 67 |  |  |  | 29d |  |  |
| 72 | 1.3.6.6 | DD Issues Resolved |  | 1d | 2016-09-20 | 2016-09-20 | 69, 71, 68 |  |  |  | 0d |  |  |
| 73 | 1.3.6.7 | Constructability Review &/or Construction Staff Comments |  | 1d | 2016-08-21 | 2016-08-21 | 67 | 1996-12-23 | 1996-12-23 | 1d | 31d |  | start no earlier than 1997-11-23 |
| 74 | 1.3.6.8 | Permits Review Checklist |  | 1d | 2016-08-21 | 2016-08-21 | 67 |  |  |  | 31d |  |  |
| 75 | 1.3.6.9 | EIE/ Record of Decision |  | 1d | 2016-08-21 | 2016-08-21 | 67 |  |  |  | 31d |  | start no earlier than 1997-11-30 |
| 76 | 1.3.6.10 | FM Global Review |  | 1d | 2016-08-21 | 2016-08-21 | 67 |  |  |  | 31d |  |  |
| 77 | 1.3.6.11 | Equipment/NIC & Telecom /Data, ART |  | 1d | 2016-08-21 | 2016-08-21 | 67 |  |  |  | 31d |  |  |
| 78 | 1.3.6.12 | Consultant Performance Evaluation |  | 1d | 2016-09-21 | 2016-09-21 | 72 |  |  |  | 0d |  |  |
| 79 | 1.3.6.13 | Notice to Proceed with Construction Documents | milestone | 0d | 2016-09-21 | 2016-09-21 | 72, 73, 74, 75, 76, 77, 78 |  |  |  | 0d |  |  |
| 80 | 1.3.7 | **Contract Documents (Final Design)** |  | 185d | 2016-09-22 | 2017-03-25 | 79 | 1996-12-23 | 1997-02-14 | 40d | 0d |  |  |
| 81 | 1.3.7.1 | Construction Drawings ( * PM to adjust for each project ) |  | 130d | 2016-09-22 | 2017-01-29 | 79 |  |  |  | 0d |  |  |
| 82 | 1.3.7.2 | CDs 50% Submission - Milestone | milestone | 0d | 2016-11-30 | 2016-11-30 | 81FF-60d |  |  |  | 31d | 0d |  |
| 83 | 1.3.7.3 | Contract Documents 50% Review |  | 30d | 2016-12-01 | 2016-12-30 | 81FS-60d, 82 | 1996-12-23 | 1996-12-23 | 1d | 31d | 30d | start no earlier than 1997-12-28 |
| 84 | 1.3.7.4 | Receive 100% CDs for Review | milestone | 0d | 2017-01-29 | 2017-01-29 | 81, 83 |  |  |  | 1d | 0d |  |
| 85 | 1.3.7.5 | Contract Documents 100% Review, Agency Approval |  | 30d | 2017-01-30 | 2017-02-28 | 81, 84 | 1996-12-23 | 1996-12-23 | 1d | 1d |  | start no earlier than 1997-12-21 |
| 86 | 1.3.7.6 | Land Acq./Easements Final Confirmation |  | 1d | 2017-01-30 | 2017-01-30 | 81 |  |  |  | 30d |  |  |
| 87 | 1.3.7.7 | Redicheck |  | 30d | 2017-01-30 | 2017-02-28 | 81 | 1996-12-23 | 1997-01-03 | 10d | 0d |  | start no earlier than 1998-01-25 |
| 88 | 1.3.7.8 | Submit CD's to SBI/SFM |  | 30d | 2017-01-30 | 2017-02-28 | 81 |  |  |  | 0d |  | start no earlier than 1998-06-28 |
| 89 | 1.3.7.9 | Budget Reconciliation |  | 1d | 2017-01-30 | 2017-01-30 | 81 |  |  |  | 30d |  |  |
| 90 | 1.3.7.10 | CD Issues Resolved |  | 1d | 2017-03-01 | 2017-03-01 | 87, 88 |  |  |  | 0d |  |  |
| 91 | 1.3.7.11 | Notice to Proceed with T&Ms |  | 1d | 2017-03-02 | 2017-03-02 | 90, 89, 88, 87, 86, 85 |  |  |  | 0d |  |  |
| 92 | 1.3.7.12 | Final Review of "Const Phasing & Coordination Items" with A/E & Agency |  | 1d | 2017-03-03 | 2017-03-03 | 91 |  |  |  | 0d |  |  |
| 93 | 1.3.7.13 | T&Ms: Docs. ready for Bid XAdjust Time?X [Code Comments+ Redicheck +?] |  | 21d | 2017-03-04 | 2017-03-24 | 92 | 1996-12-23 | 1997-01-03 | 10d | 0d |  | start no earlier than 1998-02-08 |
| 94 | 1.3.7.14 | Certificate of Compliance Sign-offs |  | 1d | 2017-03-03 | 2017-03-03 | 91 | 1996-12-23 | 1996-12-23 | 1d | 21d |  |  |
| 95 | 1.3.7.15 | Building & Other Permits/Spec. Inspections |  | 1d | 2017-03-03 | 2017-03-03 | 91 | 1996-12-23 | 1996-12-23 | 1d | 21d |  | start no earlier than 1998-08-02 |
| 96 | 1.3.7.16 | Permits Review Checklist |  | 1d | 2017-03-03 | 2017-03-03 | 91 |  |  |  | 21d |  |  |
| 97 | 1.3.7.17 | Assign Inspection Staff (or Firm) for Code & CA |  | 1d | 2017-03-03 | 2017-03-03 | 91 |  |  |  | 25d | 21d |  |
| 98 | 1.3.7.18 | Confirm Project Budgets & Funds for Award |  | 1d | 2017-03-03 | 2017-03-03 | 91 |  |  |  | 25d | 21d |  |
| 99 | 1.3.7.19 | Consultant Performance Evaluation |  | 1d | 2017-03-03 | 2017-03-03 | 91 |  |  |  | 25d | 21d |  |
| 100 | 1.3.7.20 | Building Permit Received and all permits in place | milestone | 0d | 2017-03-24 | 2017-03-24 | 95, 96, 93, 94 |  |  |  | 0d |  |  |
| 101 | 1.3.7.21 | Prepare Package for Bid Unit (w/Team QC) |  | 1d | 2017-03-25 | 2017-03-25 | 93 | 1996-12-23 | 1996-12-23 | 1d | 3d |  | start no earlier than 1998-08-02 |
| 102 | 1.3.7.22 | Bid Release Form & Approval (by Chief Architect Sign-off) | milestone | 0d | 2017-03-24 | 2017-03-24 | 93, 97, 98, 99, 100 |  |  |  | 4d |  |  |

| ID | WBS | Task | Type | Duration | Start | Finish | Predecessors | Baseline start | Baseline finish | Baseline duration | Total slack | Free slack | Constraint |
| --- | --- | --- | --- | --- | --- | --- | --- | --- | --- | --- | --- | --- | --- |
| 103 | 1.4 | **Construction Bid Advertisement w/ Document Preparation** |  | 56d | 2017-03-25 | 2017-05-19 |  | 1996-12-23 | 1997-01-31 | 30d | 0d |  |  |
| 104 | 1.4.1 | Design Firm provides Contract Documents for Bidding + Bid Data Sheet |  | 3d | 2017-03-25 | 2017-03-27 | 93, 100 |  |  |  | 0d |  |  |
| 105 | 1.4.2 | $ - PM Confirms Const. Est. and Funding Approvals |  | 1d | 2017-03-25 | 2017-03-25 | 93 |  |  |  | 3d |  |  |
| 106 | 1.4.3 | PM & Design Firm confirm T&M QC/QA (& corrections) |  | 1d | 2017-03-28 | 2017-03-28 | 104 |  |  |  | 0d |  |  |
| 107 | 1.4.4 | PM delivers Docs. To Bid Room w/ Bid Release (Milestone #4) | milestone | 0d | 2017-03-28 | 2017-03-28 | 106, 105, 101, 102 |  |  |  | 0d |  |  |
| 108 | 1.4.5 | Bidding Receives Docs. & does QA & page Check |  | 7d | 2017-03-29 | 2017-04-04 | 106 |  |  |  | 1d | 0d |  |
| 109 | 1.4.6 | Bidding Reviews Bid Release, then Prepares Bid Forms |  | 5d | 2017-03-29 | 2017-04-02 | 107 |  |  |  | 0d |  |  |
| 110 | 1.4.7 | Bidding Requests Wage Rates |  | 1d | 2017-04-05 | 2017-04-05 | 108 |  |  |  | 2d |  |  |
| 111 | 1.4.8 | Bidding Prepares Newspaper Advertisement & CoreCT PO |  | 2d | 2017-04-05 | 2017-04-06 | 108 |  |  |  | 1d |  |  |
| 112 | 1.4.9 | Print Bid Documents |  | 5d | 2017-04-03 | 2017-04-07 | 109 |  |  |  | 0d |  |  |
| 113 | 1.4.10 | Const. Bid Advertisement's) Via DAS + DCS Web (Milestone #5) | milestone | 0d | 2017-04-07 | 2017-04-07 | 110, 111, 112 |  |  |  | 0d |  |  |
| 114 | 1.4.11 | GCs Purchase Docs & Prepare Bids (PM to adjust days for small or major projects) |  | 42d | 2017-04-08 | 2017-05-19 | 113 |  |  |  | 0d |  |  |
| 115 | 1.4.12 | $ - PM Drafts Bonding Request, submit now, if schedule is critical |  | 1d | 2017-04-08 | 2017-04-08 | 113 |  |  |  | 41d |  |  |
| 116 | 1.4.13 | PM holds Pre-Bid Conference at Site |  | 1d | 2017-04-22 | 2017-04-22 | 113FS+14d |  |  |  | 27d |  |  |
| 117 | 1.4.14 | GC submits RFIs, if any (+ material substitutions?) |  | 1d | 2017-04-29 | 2017-04-29 | 113FS+21d |  |  |  | 9d | 0d |  |
| 118 | 1.4.15 | PM & Bidding issue ADDENDUM, if required (add days?, could extend time) |  | 1d | 2017-05-04 | 2017-05-04 | 113, 117FS+4d |  |  |  | 9d |  |  |
| 119 | 1.4.16 | BID OPENING ( Public Event ) (Milestone) | milestone | 0d | 2017-05-19 | 2017-05-19 | 118FS+6d, 114, 115, 116, 117 |  |  |  | 0d |  |  |
| 120 | 1.5 | **Construction Contract Award** |  | 87d | 2017-05-20 | 2017-08-14 |  |  |  |  | 0d |  |  |
| 121 | 1.5.1 | Bidding Prepares summary Bid Tab |  | 2d | 2017-05-20 | 2017-05-21 | 119 | 1996-12-23 | 1996-12-23 | 1d | 31d | 0d | start no earlier than 1998-03-08 |
| 122 | 1.5.2 | PM Confirms Resources; CA Staff, Code Inspections, Testing Lab, |  | 1d | 2017-05-22 | 2017-05-22 | 121 |  |  |  | 31d |  |  |
| 123 | 1.5.3 | Bidding Fax Document Requirements to Apparent 3 Lowest Bidders |  | 1d | 2017-05-20 | 2017-05-20 | 119 | 1996-12-23 | 1996-12-27 | 5d | 0d |  | start no earlier than 1998-03-08 |
| 124 | 1.5.4 | Bidding Submits Apparent Low Bid to PM with Bid Tab |  | 2d | 2017-05-22 | 2017-05-23 | 121 |  |  |  | 39d | 0d |  |
| 125 | 1.5.5 | GC Submits Sub Quals, Set aside, etc. |  | 14d | 2017-05-21 | 2017-06-03 | 123 | 1996-12-23 | 1997-01-17 | 20d | 0d |  | start no earlier than 1998-03-22 |
| 126 | 1.5.6 | Bidding staff reviews (& approves or rejects set aside, etc.) |  | 4d | 2017-06-04 | 2017-06-07 | 125 |  |  |  | 0d |  |  |
| 127 | 1.5.7 | Bidding Submits Bid Tab, Quals., & Request for Recommend to PM |  | 1d | 2017-06-08 | 2017-06-08 | 126 | 1996-12-23 | 1996-12-23 | 1d | 0d |  | start no earlier than 1998-08-23 |
| 128 | 1.5.8 | PM Review GC Quals, Major Subs, Etc. |  | 1d | 2017-06-09 | 2017-06-09 | 127 |  |  |  | 13d |  |  |
| 129 | 1.5.9 | PM holds SCOPE REVIEW MTG w/ Low Bidder (change 7 to 14 days - consider adding 7 more?) |  | 14d | 2017-06-09 | 2017-06-22 | 127 |  |  |  | 0d |  |  |
| 130 | 1.5.10 | PM reviews all data and drafts the Recommend to Award |  | 4d | 2017-06-23 | 2017-06-26 | 129, 122, 125, 128 | 1996-12-23 | 1997-01-31 | 30d | 0d |  | start no earlier than 1998-04-19 |
| 131 | 1.5.11 | PM Provides Recommend to Award | milestone | 0d | 2017-06-26 | 2017-06-26 | 130 | 1996-12-23 | 1996-12-23 | 1d | 0d |  | start no earlier than 1998-12-20 |
| 132 | 1.5.12 | GC Submits CHRO Plan (Bid Alternates add time) |  | 15d | 2017-05-22 | 2017-06-05 | 121 |  |  |  | 33d | 0d |  |
| 133 | 1.5.13 | CHRO Approval (working +/- w/ 21 days, CGS =60 days) |  | 21d | 2017-06-06 | 2017-06-26 | 132 |  |  |  | 33d |  |  |
| 134 | 1.5.14 | $ - PM submits Initial Bond Request |  | 15d | 2017-05-24 | 2017-06-07 | 124, 115 |  |  |  | 39d |  |  |
| 135 | 1.5.15 | $ - PM submits Final Bond Adjustment |  | 20d | 2017-06-27 | 2017-07-16 | 131 |  |  |  | 0d |  |  |
| 136 | 1.5.16 | $ - Bond Commission Mtg - Funding Approved | milestone | 0d | 2017-07-16 | 2017-07-16 | 135, 134 |  |  |  | 0d |  |  |
| 137 | 1.5.17 | Bidding Faxes & Mails Letter of Intent to GC |  | 1d | 2017-07-17 | 2017-07-17 | 136 |  |  |  | 0d |  |  |
| 138 | 1.5.18 | Fax Request to GC for Contract Documents (+ signed contract) |  | 1d | 2017-07-17 | 2017-07-17 | 136 |  |  |  | 0d |  |  |
| 139 | 1.5.19 | GC Provides Contract Documents (Bonds, Insurance, Etc.) |  | 12d | 2017-07-18 | 2017-07-29 | 138, 137 |  |  |  | 0d |  |  |
| 140 | 1.5.20 | $ - Bond Funds or other funds available |  | 12d | 2017-07-17 | 2017-07-28 | 136 |  |  |  | 1d |  |  |
| 141 | 1.5.21 | DPW Legal Approves (Corp Res., etc.) & DPW Contract Signing |  | 5d | 2017-07-30 | 2017-08-03 | 140, 133, 139 |  |  |  | 0d |  |  |
| 142 | 1.5.22 | Attorney General Approval |  | 6d | 2017-08-04 | 2017-08-09 | 141 |  |  |  | 0d |  |  |
| 143 | 1.5.23 | Legal advises Bidding and PM of AG approval |  | 1d | 2017-08-10 | 2017-08-10 | 142 |  |  |  | 0d |  |  |
| 144 | 1.5.24 | Bidding issues PO via Core CT |  | 1d | 2017-08-11 | 2017-08-11 | 143 |  |  |  | 36d | 3d |  |
| 145 | 1.5.25 | PM does Pre-Start Mtg & Contract Award without NTP |  | 4d | 2017-08-11 | 2017-08-14 | 143 |  |  |  | 0d |  |  |

| ID | WBS | Task | Type | Duration | Start | Finish | Predecessors | Baseline start | Baseline finish | Baseline duration | Total slack | Free slack |
| --- | --- | --- | --- | --- | --- | --- | --- | --- | --- | --- | --- | --- |
| 146 | 1.6 | **CONSTRUCTION PHASE (plus 60 days for punch list completion)** |  | 769d | 2017-08-14 | 2019-09-22 |  | 1996-12-23 | 1997-01-07 | 12d | 0d |  |
| 147 | 1.6.1 | Construction Contract Start Date (Milestone # 6) | milestone | 0d | 2017-08-14 | 2017-08-14 | 145, 144 |  |  |  | 33d |  |
| 148 | 1.6.2 | Testing Lab P.O. Issued |  | 1d | 2017-08-15 | 2017-08-15 | 145 |  |  |  | 32d |  |
| 149 | 1.6.3 | Pre-Construction Meeting, working procedures during const., PMWeb Use |  | 1d | 2017-08-15 | 2017-08-15 | 145 | 1996-12-23 | 1996-12-23 | 1d | 20d |  |
| 150 | 1.6.4 | GC submits "initial" 90 day CMP Approval (prepare+ review+OK) [review days &logic] |  | 21d | 2017-08-15 | 2017-09-04 | 145 |  |  |  | 0d |  |
| 151 | 1.6.5 | Establish Start Date & ISSUE "NTP" |  | 12d | 2017-09-05 | 2017-09-16 | 145, 150, 149 | 1996-12-23 | 1997-01-07 | 12d | 0d |  |
| 152 | 1.6.6 | Const Start & Duration ( * PM to adjust per contract calendar days) |  | 645d | 2017-09-17 | 2019-06-23 | 151, 147, 148 |  |  |  | 0d |  |
| 153 | 1.6.7 | Code Inspection Check List Approved by Codes (& A/E & CA) |  | 1d | 2017-09-17 | 2017-09-17 | 151 |  |  |  | 799d | 644d |
| 154 | 1.6.8 | Testing Services Start, FM Global Coordination |  | 1d | 2017-09-17 | 2017-09-17 | 151 | 1996-12-23 | 1996-12-23 | 1d | 799d | 644d |
| 155 | 1.6.9 | Utility Services (Issue P.O. if needed) + ART Status |  | 1d | 2017-09-17 | 2017-09-17 | 151 | 1996-12-23 | 1996-12-23 | 1d | 799d | 644d |
| 156 | 1.6.10 | Schedule of Values |  | 1d | 2017-09-17 | 2017-09-17 | 151 | 1996-12-23 | 1996-12-23 | 1d | 799d | 644d |
| 157 | 1.6.11 | Project Schedule (Adjust All detail Below) |  | 1d | 2017-09-17 | 2017-09-17 | 151 | 1996-12-23 | 1996-12-23 | 1d | 799d | 644d |
| 158 | 1.6.12 | Job Meetings (on-going) |  | 1d | 2017-09-17 | 2017-09-17 | 151 | 1996-12-23 | 1996-12-23 | 1d | 797d | 0d |
| 159 | 1.6.13 | Shop Drawings (on-going) |  | 1d | 2017-09-17 | 2017-09-17 | 151 | 1996-12-23 | 1996-12-23 | 1d | 797d | 0d |
| 160 | 1.6.14 | Monthly Payment Requests |  | 1d | 2019-06-24 | 2019-06-24 | 151, 152, 153, 154, 155, 156, 157 | 1996-12-23 | 1996-12-23 | 1d | 155d |  |
| 161 | 1.6.15 | RFI's (on-going) |  | 1d | 2017-09-18 | 2017-09-18 | 151, 158, 159 | 1996-12-23 | 1996-12-23 | 1d | 797d | 0d |
| 162 | 1.6.16 | Site Preparation, |  | 1d | 2017-09-17 | 2017-09-17 | 151 | 1996-12-23 | 1996-12-23 | 1d | 797d | 0d |
| 163 | 1.6.17 | Foundations |  | 1d | 2017-09-18 | 2017-09-18 | 151, 162 | 1996-12-23 | 1996-12-23 | 1d | 797d | 0d |
| 164 | 1.6.18 | Structural & Exterior |  | 1d | 2017-09-19 | 2017-09-19 | 151, 163, 161 | 1996-12-23 | 1996-12-23 | 1d | 797d | 0d |
| 165 | 1.6.19 | MEP |  | 1d | 2017-09-20 | 2017-09-20 | 151, 164 | 1996-12-23 | 1996-12-23 | 1d | 797d |  |
| 166 | 1.6.20 | Roofing, Envelope watertight |  | 1d | 2017-09-17 | 2017-09-17 | 151 |  |  |  | 553d | 0d |
| 167 | 1.6.21 | Building Interiors - MEP + Finishes + Landscaping |  | 1d | 2017-09-18 | 2017-09-18 | 151, 166 | 1996-12-23 | 1996-12-23 | 1d | 553d |  |
| 168 | 1.6.22 | Consultant and Contractor Performance Evaluations at 50% |  | 1d | 2017-09-17 | 2017-09-17 | 151 |  |  |  | 554d |  |
| 169 | 1.6.23 | Other Systems ( Fire Alarm, Security, Communications, etc) |  | 1d | 2017-09-17 | 2017-09-17 | 151 | 1996-12-23 | 1996-12-23 | 1d | 554d |  |
| 170 | 1.6.24 | Substantial Completion Prep. - see check list, GC to start now |  | 90d | 2019-03-26 | 2019-06-23 | 152FF, 167, 168, 169 |  |  |  | 0d |  |
| 171 | 1.6.25 | Equipment & Telecom/Data & Art Completion |  | 1d | 2017-09-17 | 2017-09-17 | 151 | 1996-12-23 | 1996-12-23 | 1d | 644d |  |
| 172 | 1.6.26 | Change Orders XTake any add time from Weather & Punch list-FF134X |  | 1d | 2019-06-23 | 2019-06-23 | 152FF | 1996-12-23 | 1996-12-23 | 1d | 1d |  |
| 173 | 1.6.27 | Weather Delays and/or Float ( * PM to adjust per Project) XNOTE FFXX |  | 14d | 2019-06-10 | 2019-06-23 | 152FF |  |  |  | 1d |  |
| 174 | 1.6.28 | System Demonstration & Training |  | 1d | 2017-09-17 | 2017-09-17 | 151 |  |  |  | 644d |  |
| 175 | 1.6.29 | Commission Building Systems |  | 1d | 2019-06-24 | 2019-06-24 | 151, 170, 171, 174 | 1996-12-23 | 1996-12-23 | 1d | 0d |  |
| 176 | 1.6.30 | Punch List Items (ALL CODE & LIFE SAFETY items to be completed prior to use ) |  | 1d | 2019-06-25 | 2019-06-25 | 173, 175, 174, 172 |  |  |  | 0d |  |
| 177 | 1.6.31 | Certificate of Compliance + DPW Code Projects, Code Unit sign off | milestone | 0d | 2019-06-25 | 2019-06-25 | 176 |  |  |  | 0d |  |
| 178 | 1.6.32 | Certificate of Occupancy - OSBI Projects | milestone | 0d | 2019-06-25 | 2019-06-25 | 176 |  |  |  | 0d |  |
| 179 | 1.6.33 | Substantial Completion (Milestone # 7) | milestone | 0d | 2019-06-28 | 2019-06-28 | 176FS+1d, 177FS+3d, 178FS+3d |  |  |  | 86d | 0d |
| 180 | 1.6.34 | Punch List (any remaining minor items) [off gassing?, Start Agency move in after 45 days?] |  | 89d | 2019-06-26 | 2019-09-22 | 176, 177, 178, 175 |  |  |  | 0d |  |
| 181 | 1.6.35 | Record Drawings |  | 1d | 2019-06-26 | 2019-06-26 | 176 |  |  |  | 118d |  |
| 182 | 1.6.36 | Operations and Maintenance Manuals |  | 1d | 2019-06-26 | 2019-06-26 | 176 |  |  |  | 88d |  |

| ID | WBS | Task | Type | Duration | Start | Finish | Predecessors | Baseline start | Baseline finish | Baseline duration | Total slack | Constraint |
| --- | --- | --- | --- | --- | --- | --- | --- | --- | --- | --- | --- | --- |
| 183 | 1.7 | **Move In** |  | 30d | 2019-09-22 | 2019-10-22 |  |  |  |  | 0d |  |
| 184 | 1.7.1 | Turnover Letter to Agency | milestone | 0d | 2019-09-22 | 2019-09-22 | 179, 180, 182 |  |  |  | 0d |  |
| 185 | 1.7.2 | FF&E Tasks, ART |  | 5d | 2019-09-23 | 2019-09-27 | 184 |  |  |  | 25d |  |
| 186 | 1.7.3 | Agency Move-in & Operations start up XSTART WHEN?X |  | 20d | 2019-09-23 | 2019-10-12 | 184 |  |  |  | 0d |  |
| 187 | 1.7.4 | Other Admin Issues |  | 10d | 2019-10-13 | 2019-10-22 | 186 |  |  |  | 0d |  |
| 188 | 1.7.5 | AGENCY USE OF FACILITY - first day of business use | milestone | 0d | 2019-10-22 | 2019-10-22 | 187, 184, 185 |  |  |  | 0d |  |
| 189 | 1.8 | **Close Out / Administrative** |  | 151d | 2019-06-29 | 2019-11-26 |  | 1996-12-23 | 1997-03-14 | 60d | 0d |  |
| 190 | 1.8.1 | Consultant's) and Contractor Perf Evaluations w/in 90 days of SC |  | 1d | 2019-09-23 | 2019-09-23 | 184 |  |  |  | 29d |  |
| 191 | 1.8.2 | As-Builts |  | 30d | 2019-06-29 | 2019-07-28 | 179 |  |  |  | 86d |  |
| 192 | 1.8.3 | Certificate of Acceptance (Milestone #8) | milestone | 0d | 2019-10-22 | 2019-10-22 | 191, 181, 188, 190 |  |  |  | 0d |  |
| 193 | 1.8.4 | Close Out-Office |  | 30d | 2019-10-23 | 2019-11-21 | 192 |  |  |  | 0d |  |
| 194 | 1.8.5 | Warranties/Guarantees |  | 1d | 2019-11-22 | 2019-11-22 | 193 |  |  |  | 0d |  |
| 195 | 1.8.6 | Insurance Certificate |  | 1d | 2019-11-23 | 2019-11-23 | 194 |  |  |  | 0d |  |
| 196 | 1.8.7 | Final Commissioning + LEED Submission XX After final payment?XX |  | 1d | 2019-11-24 | 2019-11-24 | 195 |  |  |  | 0d |  |
| 197 | 1.8.8 | Post Project Evaluation |  | 1d | 2019-11-25 | 2019-11-25 | 196 |  |  |  | 0d |  |
| 198 | 1.8.9 | Other Open Issues (claims, etc.) |  | 1d | 2019-11-26 | 2019-11-26 | 197 |  |  |  | 0d | start no earlier than 1999-11-14 |
| 199 | 1.8.10 | Final Payment (Milestone) | milestone | 0d | 2019-11-26 | 2019-11-26 | 198, 191, 184 |  |  |  | 0d |  |
| 200 | 1.9 | Note: Time is based on Calendar days (30 days = 1 month) | milestone | 0d | 2019-11-26 | 2019-11-26 | 199 |  |  |  | 0d |  |
| 201 | 1.10 | Note June update add "Initial CMP" submission & approval (added 21days) | milestone | 0d | 2019-11-26 | 2019-11-26 | 200 |  |  |  | 0d |  |
| 202 | 1.11 | Note July update increased Contract processing time from 30 days to 45 days (added 15 days ) | milestone | 0d | 2019-11-26 | 2019-11-26 | 201 |  |  |  | 0d |  |
| 203 | 1.12 | Note General Edit (now template 3e) | milestone | 0d | 2019-11-26 | 2019-11-26 | 202 |  |  |  | 0d |  |
