# CMR Outline Generic 150408

Schedule from MS Project, 2015-04-06 to 2019-07-25.

## Calendars

- Standard: Mon-Sun 08:00-12:00, 13:00-17:00.

## Schedule

| ID | WBS | Task | Type | Duration | Start | Finish | Predecessors | Baseline start | Baseline finish | Baseline duration | Total slack | Constraint |
| --- | --- | --- | --- | --- | --- | --- | --- | --- | --- | --- | --- | --- |
| 1 | 1 | **CMR Outline Formal Project ( $50,000,000+/-)** |  | 1572d | 2015-04-06 | 2019-07-25 |  |  |  |  | 0d |  |
| 2 | 1.1 | **Agency Planning & OPM-B100 Process[1YR]** |  | 0d | 2015-04-06 | 2015-04-06 |  | 1996-12-23 | 1997-04-25 | 90d | 0d |  |
| 3 | 1.1.1 | NOTE: see Large DBB Template for additional required DETAIL | milestone | 0d | 2015-04-06 | 2015-04-06 |  |  |  |  | 1572d |  |
| 4 | 1.1.2 | Agency Program Development (3mo.) | milestone | 0d | 2015-04-06 | 2015-04-06 |  | 1996-12-23 | 1997-04-25 | 90d | 0d |  |
| 5 | 1.1.3 | State-OPM Capitol Budget Process (12mo.) | milestone | 0d | 2015-04-06 | 2015-04-06 | 4 |  |  |  | 0d |  |
| 6 | 1.1.4 | AGENCY PLANNING, + Equipment, etc. (3mo.) | milestone | 0d | 2015-04-06 | 2015-04-06 | 5 | 1996-12-23 | 1997-04-25 | 90d | 0d |  |
| 8 | 1.2 | **Project Initiation and DPW Planning** |  | 30d | 2015-04-06 | 2015-05-05 | 6 | 1996-12-23 | 1997-04-24 | 89d | 0d |  |
| 9 | 1.2.1 | Receive Client Agency B-100S | milestone | 0d | 2015-04-06 | 2015-04-06 | 6 |  |  |  | 0d |  |
| 10 | 1.2.2 | Review B-100 Supplement w/Agency & Accept |  | 15d | 2015-04-06 | 2015-04-20 | 9 | 1996-12-23 | 1997-01-03 | 10d | 0d |  |
| 11 | 1.2.3 | Project Plan - Prepare and Approve |  | 15d | 2015-04-21 | 2015-05-05 | 10 |  |  |  | 0d |  |
| 12 | 1.2.4 | Commissioner Approval of CMR Delivery Method | milestone | 0d | 2015-05-05 | 2015-05-05 | 11 |  |  |  | 0d |  |
| 13 | 1.2.5 | In Take Mtg &/or Project Plan Approval | milestone | 0d | 2015-05-05 | 2015-05-05 | 12 |  |  |  | 0d |  |
| 14 | 1.3 | **Design Firm & CA- Adv & Select & Bonding + Contract** |  | 251d | 2015-05-05 | 2016-01-11 | 13 |  |  |  | 0d |  |
| 15 | 1.3.1 | A/E Advertisement (A/E will provide FTP site) |  | 15d | 2015-05-06 | 2015-05-20 | 13 | 1997-01-03 | 1997-04-24 | 80d | 0d |  |
| 16 | 1.3.2 | OR/CA Advertisement with future CxA Sub | milestone | 0d | 2015-05-05 | 2015-05-05 | 13 |  |  |  | 15d |  |
| 17 | 1.3.3 | A/E Quals Prep & Submission (and CA/OR w/ CxA) |  | 28d | 2015-05-21 | 2015-06-17 | 16, 15 |  |  |  | 0d |  |
| 18 | 1.3.4 | A/E (& CA) Selection (Short list, then Interview, Admin Steps) |  | 39d | 2015-06-18 | 2015-07-26 | 17 |  |  |  | 0d |  |
| 19 | 1.3.5 | Conditional Selection Notice to A/E and OR Firms | milestone | 0d | 2015-07-26 | 2015-07-26 | 18 |  |  |  | 0d |  |
| 20 | 1.3.6 | Negotiation & Scoping by PM (Exhibit A) A/E & OR |  | 26d | 2015-07-27 | 2015-08-21 | 19 | 1996-12-23 | 1997-01-10 | 15d | 0d |  |
| 21 | 1.3.7 | Request Credentials, Etc. ( by Legal & PM) |  | 30d | 2015-07-27 | 2015-08-25 | 19 |  |  |  | 1430d |  |
| 22 | 1.3.8 | Process Contract & Credentials, Etc. by Legal (w/ PM) |  | 85d | 2015-08-22 | 2015-11-14 | 20 | 1996-12-23 | 1997-02-07 | 35d | 0d | start no earlier than 1997-05-11 |
| 23 | 1.3.9 | Submit A/E and CA Contracts to SPRB | milestone | 0d | 2015-11-14 | 2015-11-14 | 22 |  |  |  | 0d |  |
| 24 | 1.3.10 | SPRB Approval (A/E and CA w/ CxA) |  | 14d | 2015-11-15 | 2015-11-28 | 23 |  |  |  | 0d |  |
| 25 | 1.3.11 | Request Bonding for Design (and for CA and CMR Pre-Const.) |  | 30d | 2015-11-29 | 2015-12-28 | 24 | 1996-12-23 | 1997-01-17 | 20d | 0d | start no earlier than 1997-12-28 |
| 26 | 1.3.12 | Bonding Approved | milestone | 0d | 2015-12-28 | 2015-12-28 | 25 |  |  |  | 0d |  |
| 27 | 1.3.13 | Administrative Steps, DPW Approval, Submit to AG for A/E and CA |  | 7d | 2015-12-29 | 2016-01-04 | 26 |  |  |  | 0d |  |
| 28 | 1.3.14 | AG Approval |  | 7d | 2016-01-05 | 2016-01-11 | 27 |  |  |  | 0d |  |
| 29 | 1.3.15 | NTP for Design - A/E & CA | milestone | 0d | 2016-01-11 | 2016-01-11 | 28 |  |  |  | 0d |  |

| ID | WBS | Task | Type | Duration | Start | Finish | Predecessors | Baseline start | Baseline finish | Baseline duration | Total slack | Free slack | Constraint |
| --- | --- | --- | --- | --- | --- | --- | --- | --- | --- | --- | --- | --- | --- |
| 30 | 1.4 | **Owners Rep hires Commissioning Agent, Select., Neg & Contract** |  | 183d | 2015-07-27 | 2016-01-25 | 19 |  |  |  | 1277d |  |  |
| 31 | 1.4.1 | Comm. Agent - via CA - Selection steps in flex. |  | 21d | 2015-07-27 | 2015-08-16 | 19 |  |  |  | 1397d | 0d |  |
| 32 | 1.4.2 | Negotiation & Scoping |  | 14d | 2015-08-17 | 2015-08-30 | 31 |  |  |  | 1397d | 0d |  |
| 33 | 1.4.3 | Process w/CA Contract. NOTE: if Commission letter, plan 90+ days for approve. |  | 14d | 2015-08-31 | 2015-09-13 | 32 |  |  |  | 1397d | 120d |  |
| 34 | 1.4.4 | CA Processes Sub Contract w/CxA |  | 14d | 2016-01-12 | 2016-01-25 | 33, 29 |  |  |  | 1277d | 0d |  |
| 35 | 1.4.5 | Comm. Agent NTP for Design phase services | milestone | 0d | 2016-01-25 | 2016-01-25 | 34 |  |  |  | 1277d |  |  |
| 37 | 1.5 | **CMR Firm Selection - QBS Short Listing Steps** |  | 32d | 2015-12-28 | 2016-01-29 | 26 |  |  |  | 18d |  |  |
| 38 | 1.5.1 | (*AAA145) QBS "CMR Advertisement", when A/E Fee is Bonded (or A/E Scope 100% done) | milestone | 0d | 2015-12-28 | 2015-12-28 | 26 |  |  |  | 18d | 0d |  |
| 39 | 1.5.2 | CMR Quals Prep & Submission |  | 21d | 2015-12-29 | 2016-01-18 | 38 |  |  |  | 18d | 0d |  |
| 40 | 1.5.3 | PM (or Team) does reference checks /calls on firms. (say 2 man day effort) |  | 5d | 2016-01-19 | 2016-01-23 | 39 |  |  |  | 18d | 0d |  |
| 41 | 1.5.4 | CMR Short Listing Meeting and Admin Steps (2+4) |  | 6d | 2016-01-24 | 2016-01-29 | 40 |  |  |  | 18d | 0d |  |
| 42 | 1.5.5 | (*AAA146) CMR Shortlist Notice to four firms | milestone | 0d | 2016-01-29 | 2016-01-29 | 41 |  |  |  | 18d |  |  |
| 45 | 1.6 | **A/E Design Phase Services & CA Services** |  | 481d | 2016-01-11 | 2017-05-06 | 29 |  |  |  | 0d |  |  |
| 46 | 1.6.1 | Design Start - Kick off meeting | milestone | 0d | 2016-01-11 | 2016-01-11 | 29 |  |  |  | 0d |  |  |
| 47 | 1.6.2 | Programming Effort, plus Environ & Permits Review |  | 22d | 2016-01-12 | 2016-02-02 | 46 |  |  |  | 0d |  |  |
| 48 | 1.6.3 | DPW and Agency Review of Programming Report |  | 10d | 2016-02-03 | 2016-02-12 | 47 |  |  |  | 11d | 0d |  |
| 49 | 1.6.4 | Program Approved and NTP for schematics | milestone | 0d | 2016-02-12 | 2016-02-12 | 48 |  |  |  | 11d | 0d |  |
| 50 | 1.6.5 | Schematic Design Preparation + Reviews [Real Durations?- ADD DAYS!] |  | 75d | 2016-02-13 | 2016-04-27 | 49 | 1996-12-23 | 1997-01-17 | 20d | 750d | 0d | start no earlier than 1997-08-24 |
| 51 | 1.6.6 | NTP with DDs | milestone | 0d | 2016-04-27 | 2016-04-27 | 50 |  |  |  | 750d | 0d |  |
| 52 | 1.6.7 | CMR should be selected & providing input at this time |  | 30d | 2016-04-28 | 2016-05-27 | 51 |  |  |  | 750d | 0d |  |
| 53 | 1.6.8 | Design Development Preparation + Reviews [Real Durations? -ADD DAYS!] |  | 90d | 2016-05-28 | 2016-08-25 | 52, 51 | 1996-12-23 | 1997-01-31 | 30d | 750d | 0d | start no earlier than 1997-10-05 |
| 54 | 1.6.9 | NTP w/ CDs | milestone | 0d | 2016-08-25 | 2016-08-25 | 53 |  |  |  | 750d | 0d |  |
| 55 | 1.6.10 | CMR is now providing input into Docs (Plans & Specs) |  | 30d | 2016-08-26 | 2016-09-24 | 54 |  |  |  | 750d | 0d |  |
| 56 | 1.6.11 | Contract Documents Preparation (w/ Cost Review @ 50%) |  | 90d | 2016-09-25 | 2016-12-23 | 55, 54 | 1996-12-23 | 1997-02-14 | 40d | 750d | 0d |  |
| 57 | 1.6.12 | Redi-Check & other reviews |  | 30d | 2016-12-24 | 2017-01-22 | 56 |  |  |  | 750d | 0d |  |
| 58 | 1.6.13 | Design Firm Completes Contract Documents + OSBI Submission |  | 60d | 2017-01-23 | 2017-03-23 | 57 |  |  |  | 750d | 0d |  |
| 59 | 1.6.14 | Permits Received, all Approvals in place |  | 30d | 2017-03-24 | 2017-04-22 | 58 |  |  |  | 750d | 0d |  |
| 60 | 1.6.15 | Client Agency OK & DPW (w/ Bid Release Form) |  | 14d | 2017-04-23 | 2017-05-06 | 59, 57, 58 | 1996-12-23 | 1996-12-23 | 1d | 750d | 0d | start no earlier than 1998-08-02 |
| 61 | 1.6.16 | (*AAA 210) Contract Docs. Package to CMR - 100+/-% Complete | milestone | 0d | 2017-05-06 | 2017-05-06 | 60 |  |  |  | 750d | 0d |  |

| ID | WBS | Task | Type | Duration | Start | Finish | Predecessors | Total slack | Free slack |
| --- | --- | --- | --- | --- | --- | --- | --- | --- | --- |
| 63 | 1.7 | **A/E and CA Bidding Support Services** |  | 60d | 2017-05-07 | 2017-07-05 | 61 | 750d |  |
| 64 | 1.7.1 | A/E & CA Support Trade Bids Preparation |  | 30d | 2017-05-07 | 2017-06-05 | 61 | 750d | 0d |
| 65 | 1.7.2 | A/E & CA Support Trade Bids and Scope Reviews |  | 30d | 2017-06-06 | 2017-07-05 | 64 | 750d |  |
| 67 | 1.8 | **CMR Firm Selection via Best Value RFP w/Cost Proposal** |  | 133d | 2016-02-13 | 2016-06-24 | 11 | 4d |  |
| 68 | 1.8.1 | PM prepares CMR "RFP Package" w/scope detail + Program Doc. |  | 14d | 2016-02-13 | 2016-02-26 | 26, 41, 49 | 1217d | 0d |
| 69 | 1.8.2 | PM processes Prel. Bid Release Form for approval of $$, LDs, Schedule, etc. |  | 7d | 2016-02-27 | 2016-03-04 | 68 | 1224d | 7d |
| 70 | 1.8.3 | Design Firm posts the FTP Site Documents including a word "Table of Contents" |  | 14d | 2016-02-27 | 2016-03-11 | 68 | 1217d | 0d |
| 71 | 1.8.4 | PM (or Process Man) prepares the RFP (PM has "Bid Release Form" & Final Program) |  | 14d | 2016-03-12 | 2016-03-25 | 69, 70 | 1217d |  |
| 72 | 1.8.5 | RFP pick up date Notice to four CMR Firms |  | 7d | 2016-02-17 | 2016-02-23 | 42, 47FS+14d | 0d |  |
| 73 | 1.8.6 | RFP Package completion -prep by DPW PM (w/A/E support?) +Printing |  | 7d | 2016-02-24 | 2016-03-01 | 72, 49 | 0d |  |
| 74 | 1.8.7 | (*AAA141) RFP Packages to shortlisted CMR Firms | milestone | 0d | 2016-03-01 | 2016-03-01 | 73, 49 | 0d |  |
| 75 | 1.8.8 | Pre-Proposal Meeting |  | 7d | 2016-03-02 | 2016-03-08 | 74 | 0d |  |
| 76 | 1.8.9 | CMRs Prepare Proposals & "Submit Questions" [add time ?] |  | 21d | 2016-03-09 | 2016-03-29 | 75 | 0d |  |
| 77 | 1.8.10 | Issue RFP Addendum, as required |  | 4d | 2016-03-30 | 2016-04-02 | 76 | 0d |  |
| 78 | 1.8.11 | CMRs complete proposal preparation |  | 20d | 2016-04-03 | 2016-04-22 | 77 | 0d |  |
| 79 | 1.8.12 | (*AAA142) CMR Best Value Proposals Rec'd by DPW | milestone | 0d | 2016-04-22 | 2016-04-22 | 78 | 0d |  |
| 80 | 1.8.13 | Proposal Review, INTERVIEWs & "B.V." Selection by DPW |  | 5d | 2016-04-23 | 2016-04-27 | 79 | 0d |  |
| 81 | 1.8.14 | Best Value Selection + Admin steps + Commissioners Approval |  | 5d | 2016-04-28 | 2016-05-02 | 80 | 0d |  |
| 82 | 1.8.15 | (*AAA143) Conditional Selection Notice to Selected CMR (+ CHRO notice) | milestone | 0d | 2016-05-02 | 2016-05-02 | 81 | 0d |  |
| 83 | 1.8.16 | Legal & PM prepare CMR Agreement + (ExhibitB) via RFP & cost proposal |  | 28d | 2016-05-03 | 2016-05-30 | 82 | 0d |  |
| 84 | 1.8.17 | Credentials & Other Admin by legal + PM |  | 21d | 2016-05-03 | 2016-05-23 | 82 | 1158d |  |
| 85 | 1.8.18 | CHRO Plan Approval (30+days?) |  | 28d | 2016-05-03 | 2016-05-30 | 82 | 1151d |  |
| 86 | 1.8.19 | Bonding for Pre-Const handled w/design contract (or add days) |  | 1d | 2016-05-31 | 2016-05-31 | 83 | 0d |  |
| 87 | 1.8.20 | Admin Steps and Contract Approved by DPW and sent to AG |  | 14d | 2016-06-01 | 2016-06-14 | 86 | 0d |  |
| 88 | 1.8.21 | AG Approval |  | 10d | 2016-06-15 | 2016-06-24 | 87 | 0d |  |

| ID | WBS | Task | Type | Duration | Start | Finish | Predecessors | Baseline start | Baseline finish | Baseline duration | Total slack | Free slack | Constraint |
| --- | --- | --- | --- | --- | --- | --- | --- | --- | --- | --- | --- | --- | --- |
| 90 | 1.9 | **CMR Pre-Construction Services (duration as needed - to GMP Submission)** |  | 90d | 2016-06-24 | 2016-09-22 | 88 |  |  |  | 0d |  |  |
| 91 | 1.9.1 | (*AAA161) DPW issues CMR Notice to Proceed Pre-Construction Services | milestone | 0d | 2016-06-24 | 2016-06-24 | 88 |  |  |  | 0d |  |  |
| 92 | 1.9.2 | NOTE - Consider Early Work Packages (WAOs)for Demo/ Utilities/ Other |  | 30d | 2016-06-25 | 2016-07-24 | 91 |  |  |  | 1096d |  |  |
| 93 | 1.9.3 | CMR Starts Pre-Construction Services (duration as needed) |  | 90d | 2016-06-25 | 2016-09-22 | 91 |  |  |  | 0d |  |  |
| 95 | 1.10 | **CMR Processes Trade Bids (part of Pre-Construction Services )** |  | 226d | 2016-09-23 | 2017-05-06 | 93 |  |  |  | 0d |  |  |
| 96 | 1.10.1 | (*AAA211) PM processes the Bid Release Form to obtain approval to Advertise. | milestone | 0d | 2017-05-06 | 2017-05-06 | 93, 61 |  |  |  | 810d |  |  |
| 97 | 1.10.2 | DPW Trades Bid package & Instructions to CMR w/mtg(?) |  | 5d | 2016-09-23 | 2016-09-27 | 93 |  |  |  | 0d |  |  |
| 98 | 1.10.3 | CMR Reviews CDs and Adjusts for Trade Bids, Some A/E effort on Drawings |  | 14d | 2016-09-28 | 2016-10-11 | 97 |  |  |  | 0d |  |  |
| 99 | 1.10.4 | CMR Prepares, packages Trade Bids [w/support by A/E Re: Docs.] |  | 14d | 2016-10-12 | 2016-10-25 | 98 |  |  |  | 0d |  |  |
| 100 | 1.10.5 | (*AAA220) Advertise Trade Bids ( CMR + DPW + DAS Web Sites) | milestone | 0d | 2016-10-25 | 2016-10-25 | 99, 97 |  |  |  | 0d |  |  |
| 101 | 1.10.6 | receive RFI / Substitutions requests |  | 14d | 2016-09-23 | 2016-10-06 |  |  |  |  | 1022d |  |  |
| 102 | 1.10.7 | Trades Prepare Bids (+ issue addenda, A/E w/CMR) |  | 28d | 2016-10-26 | 2016-11-22 | 100 | 1996-12-23 | 1997-01-17 | 20d | 0d |  | start no earlier than 1998-03-22 |
| 103 | 1.10.8 | (*AAA229??) Bid Opening by CMR |  | 5d | 2016-11-23 | 2016-11-27 | 102 | 1996-12-23 | 1996-12-23 | 1d | 0d |  | start no earlier than 1998-04-19 |
| 104 | 1.10.9 | (*AAA230) Summary Trade Bid Results Review (Bid Tabs w/comments) | milestone | 0d | 2016-11-27 | 2016-11-27 | 103 |  |  |  | 0d |  |  |
| 105 | 1.10.10 | (*AAA260) Scope Review w/ Trade Bidder | milestone | 0d | 2016-11-27 | 2016-11-27 | 104 |  |  |  | 0d |  |  |
| 106 | 1.10.11 | Review Bids, Scope Rev., CHRO plan update |  | 12d | 2016-11-28 | 2016-12-09 | 105 | 1996-12-23 | 1997-01-31 | 30d | 0d |  | start no earlier than 1998-04-19 |
| 107 | 1.10.12 | Bonding Request Place Holder, if needed |  | 1d | 2016-12-10 | 2016-12-10 | 106 |  |  |  | 957d |  |  |
| 108 | 1.10.13 | Review "set aside results" vs. goals by CMR |  | 2d | 2016-12-10 | 2016-12-11 | 106 |  |  |  | 956d |  |  |
| 109 | 1.10.14 | CMR Recom. Trades Contract Awards |  | 4d | 2016-12-10 | 2016-12-13 | 106 |  |  |  | 0d |  |  |
| 110 | 1.10.15 | DPW "Approval" of Trade Contract Awards (when?, CA input?) |  | 3d | 2016-12-14 | 2016-12-16 | 109 |  |  |  | 0d |  |  |
| 112 | 1.11 | **CMR Provides GMP Proposal and Owner Approval (14+14+60)** |  | 65d | 2016-12-17 | 2017-02-19 | 109 |  |  |  | 0d |  |  |
| 113 | 1.11.1 | CMR Prepares the GMP with "Assumptions & Clarifications" |  | 10d | 2016-12-17 | 2016-12-26 | 110 |  |  |  | 0d |  |  |
| 114 | 1.11.2 | CMR submits the GMP (& CHRO Plan) | milestone | 0d | 2016-12-26 | 2016-12-26 | 113 |  |  |  | 0d |  |  |
| 115 | 1.11.3 | (*AAA240) PM Provides Recommend to Award | milestone | 0d | 2016-12-26 | 2016-12-26 | 114 |  |  |  | 939d | 0d |  |
| 116 | 1.11.4 | Preliminary Bonding Request - place holder |  | 2d | 2016-12-27 | 2016-12-28 | 115 |  |  |  | 939d |  |  |
| 117 | 1.11.5 | Owner Reviews & Approves GMP ( negotiates GMP) w/CA & A/E support |  | 14d | 2016-12-27 | 2017-01-09 | 114 |  |  |  | 0d |  | start no earlier than 2009-10-13 |
| 118 | 1.11.6 | CMR Submits "FINAL GMP" Submission |  | 4d | 2017-01-10 | 2017-01-13 | 117 |  |  |  | 0d |  |  |
| 119 | 1.11.7 | (*AAA241) GMP Acceptance by PM / ASPM | milestone | 0d | 2017-01-13 | 2017-01-13 | 118 |  |  |  | 0d |  |  |
| 120 | 1.11.8 | Request Bonding for Const. [ if bonding is needed - add time 30+ days ] |  | 7d | 2017-01-14 | 2017-01-20 | 119 |  |  |  | 0d |  |  |
| 121 | 1.11.9 | (*AAA 245) Bonding Approved - Funds in place | milestone | 0d | 2017-01-20 | 2017-01-20 | 120 |  |  |  | 0d |  | start no earlier than 2009-10-13 |
| 122 | 1.11.10 | Admin Steps, Bonds + Insurance, DPW Approval, Submit to AG |  | 15d | 2017-01-21 | 2017-02-04 | 121 |  |  |  | 0d |  |  |
| 123 | 1.11.11 | AG Contract Approval |  | 10d | 2017-02-05 | 2017-02-14 | 122 |  |  |  | 0d |  |  |
| 124 | 1.11.12 | Bonding & AG approval in place (reduce the 84 day duration if funding is in place) | milestone | 0d | 2017-02-14 | 2017-02-14 | 123 |  |  |  | 0d |  |  |
| 125 | 1.11.13 | Owner Issues NTP to CMR (prestart mtg needed?) |  | 5d | 2017-02-15 | 2017-02-19 | 124 |  |  |  | 0d |  | start no earlier than 2009-10-12 |

| ID | WBS | Task | Type | Duration | Start | Finish | Predecessors | Baseline start | Baseline finish | Baseline duration | Total slack | Free slack |
| --- | --- | --- | --- | --- | --- | --- | --- | --- | --- | --- | --- | --- |
| 127 | 1.12 | **CMR Manages Construction (adjust time for this project)** |  | 826d | 2017-02-19 | 2019-05-26 | 125 | 1996-12-23 | 1997-01-07 | 12d | 0d |  |
| 128 | 1.12.1 | (*AAA250) Award CMR Contract & "NTP" (& CMR issues Trade Contracts) | milestone | 0d | 2017-02-19 | 2017-02-19 | 125 | 1996-12-23 | 1996-12-23 | 1d | 0d |  |
| 129 | 1.12.2 | Actual Construction (Start + Field Work for xx months) |  | 730d | 2017-02-20 | 2019-02-19 | 128 | 1998-12-22 | 1999-12-20 | 260d | 0d |  |
| 130 | 1.12.3 | Design Team delivers "Conformed Construction Docs" [WHEN?] |  | 7d | 2017-02-20 | 2017-02-26 | 128 |  |  |  | 879d |  |
| 131 | 1.12.4 | PM to review the DBB Schedule for added construction detail |  | 1d | 2017-02-20 | 2017-02-20 | 128 |  |  |  | 885d |  |
| 132 | 1.12.5 | Confirm "Work Plan" for Substantial Completion & Acceptance |  | 90d | 2018-11-22 | 2019-02-19 | 135FF |  |  |  | 126d | 0d |
| 133 | 1.12.6 | LEED "Off Gassing" |  | 15d | 2019-02-20 | 2019-03-06 | 132 |  |  |  | 126d | 0d |
| 134 | 1.12.7 | Weather Days Allowance - per specs - say 15 days (See Spec needs edit) |  | 15d | 2019-03-07 | 2019-03-21 | 133 |  |  |  | 126d |  |
| 135 | 1.12.8 | Substantial Completion | milestone | 0d | 2019-02-19 | 2019-02-19 | 129 |  |  |  | 0d |  |
| 136 | 1.12.9 | Client Agency now Pays the Utility bills | milestone | 0d | 2019-02-19 | 2019-02-19 | 135 |  |  |  | 156d |  |
| 137 | 1.12.10 | CMR has 100% use of "Facility" for 30 days for punch list & off gassing |  | 30d | 2019-02-20 | 2019-03-21 | 135 |  |  |  | 0d |  |
| 138 | 1.12.11 | Day 31 Client Agency FF&E Delivery & installation (SC + 30 days) |  | 30d | 2019-03-22 | 2019-04-20 | 137 |  |  |  | 0d |  |
| 139 | 1.12.12 | (*AAA280) Final Completion | milestone | 0d | 2019-04-20 | 2019-04-20 | 138 |  |  |  | 0d |  |
| 140 | 1.12.13 | Day 31 Client Agency limited move in (SC + 30 days) |  | 15d | 2019-04-21 | 2019-05-05 | 139 |  |  |  | 0d |  |
| 141 | 1.12.14 | Client Agency Turn over letter 30 (or60) days after Substantial Completion 30 - start of operation? | milestone | 0d | 2019-05-05 | 2019-05-05 | 140 |  |  |  | 0d |  |
| 142 | 1.12.15 | Client Agency limited (full?) business use of the Facility (SC + 60 day) |  | 15d | 2019-05-06 | 2019-05-20 | 141 |  |  |  | 66d |  |
| 143 | 1.12.16 | Client Agency Move in 100% complete (SC + 60 days) |  | 21d | 2019-05-06 | 2019-05-26 | 141 |  |  |  | 0d |  |
| 144 | 1.12.17 | Punch List 100% complete (consider reducing to 60 Days for CMRs) |  | 90d | 2019-02-20 | 2019-05-20 | 135 |  |  |  | 66d | 0d |
| 145 | 1.12.18 | Acceptance Date | milestone | 0d | 2019-05-20 | 2019-05-20 | 144 |  |  |  | 66d |  |
| 147 | 1.13 | **A/E and CA Construction Phase Support (full duration)** |  | 780d | 2016-12-27 | 2019-02-14 | 114 |  |  |  | 161d |  |
| 148 | 1.13.1 | CA Provides GMP Review+ Neg. Support [& A/E Reviews GMP Package] |  | 30d | 2016-12-27 | 2017-01-25 | 114 |  |  |  | 911d |  |
| 149 | 1.13.2 | A/E provides Construction Phase Support (full duration) |  | 730d | 2017-02-15 | 2019-02-14 | 123 |  |  |  | 161d |  |
| 150 | 1.13.3 | CA Provides Construction Phase Support (full duration +__days) |  | 730d | 2017-02-15 | 2019-02-14 | 123 |  |  |  | 161d |  |
| 152 | 1.14 | **Client Agency Facility Operation** |  | 1d | 2019-05-26 | 2019-05-27 | 143 |  |  |  | 0d |  |
| 153 | 1.14.1 | Client Agency Business Use of Facility | milestone | 0d | 2019-05-26 | 2019-05-26 | 143 |  |  |  | 0d |  |
| 154 | 1.14.2 | Seasonal Commissioning & LEED Certification (add 179 days"?) |  | 1d | 2019-05-27 | 2019-05-27 | 153 |  |  |  | 59d |  |

| ID | WBS | Task | Type | Duration | Start | Finish | Predecessors | Baseline start | Baseline finish | Baseline duration | Total slack |
| --- | --- | --- | --- | --- | --- | --- | --- | --- | --- | --- | --- |
| 156 | 1.15 | **Close Out** |  | 156d | 2019-02-19 | 2019-07-25 | 129 | 1996-12-23 | 1997-03-14 | 60d | 0d |
| 157 | 1.15.1 | Final Payment, As Builts, Warranties (90 =21 + 60 + 9) |  | 60d | 2019-05-27 | 2019-07-25 | 153 | 1999-12-22 | 1999-12-22 | 1d | 0d |
| 158 | 1.15.2 | Certificate of Acceptance | milestone | 0d | 2019-07-25 | 2019-07-25 | 157 |  |  |  | 0d |
| 159 | 1.15.3 | Final Data Collection & Report for "HPB" + LEED efforts (say +180 days) | milestone | 0d | 2019-07-25 | 2019-07-25 | 158 |  |  |  | 0d |
| 160 | 1.15.4 | (*AAA290) Financial Closeout (Project End) | milestone | 0d | 2019-07-25 | 2019-07-25 | 159 |  |  |  | 0d |
| 161 | 1.15.5 | NOTE: This schedule is based on 30 days =1 month - move sat or sun events to the adjacent week day | milestone | 0d | 2019-07-25 | 2019-07-25 | 157 |  |  |  | 0d |
| 162 | 1.15.6 | Revision 5c added Bid Release Form in two locations | milestone | 0d | 2019-07-25 | 2019-07-25 | 157 |  |  |  | 0d |
| 163 | 1.15.7 | Revision 5d added more activities & milestones minor) and fixed logic on Trade Bides start | milestone | 0d | 2019-07-25 | 2019-07-25 | 157 |  |  |  | 0d |
| 164 | 1.15.8 | Rev 5e updated CMR Select & Agreement steps + Edited MoveInDetail | milestone | 0d | 2019-07-25 | 2019-07-25 | 157 |  |  |  | 0d |
| 165 | 1.15.9 | Rev 6 General Update | milestone | 0d | 2019-02-19 | 2019-02-19 |  |  |  |  | 156d |
| 166 | 1.15.10 | PM must adjust design & construction durations ( see maroon durations) | milestone | 0d | 2019-07-25 | 2019-07-25 | 157 |  |  |  | 0d |
